# Project Name and Number

Schedule from MS Project, 2021-02-01 to 2021-09-29.
US DOT, FhWA, CFLHD
Name the schedule with the project name, number and schedule if there is more than one. Easiest way to do multiple schedules is to create the construction schedule for all the work to be done and save it. Then when all the work has been defined into the other schedules, open the big schedule and save it as SCH A, B, or C and delete the tasks the no longer are needed and reduce the duration based on the quantities for that schedule. / 4R and heavy 3R projects probably need to be broken into phases to keep the durations lower and allow sucessors to start on that portion rather than showing, for example, excavation and embankment for 60 days (3 months) and then showing red tops starting. Red tops will normally be started once subgrade is in place for 1 to 2 miles and aggregates placed on that 1 to 2 miles while the contractor is finishing up the next couple of miles. Look at balance points or logical breaks in the project to phase the project. / On projects with multiple roads, schedule each one separately (as a phase), then tie them together based on language in the SCR's or critical path items that have to be finished on one road before the next road can be started. If asphalt can be placed on all roads with one mobilization, then stop the phases with finish aggregate base or place prime coat, and have one collective asphalt task at the bottom or the schedule. / Sometimes two phases will be worked on concurrently with 2 separate crews to accelerate completion. Know that if the completion date is set based on this scenario, prices will probably be higher because more equipment and labor will be needed and mobilization costs go up. / The production rate ranges given here-in are the result of CFL Construction Field Pool research, historic production rate data generated through EEBACS, and other resources such as RS Means and individual State DOT production rate data. These rates are provided as a baseline for generating CPM schedules; however, project specific conditions that will impact production rates should be considered by the Engineer in order to ensure an accurate construction schedule is developed.

## Calendars

- Standard: Mon-Fri 08:00-12:00, 13:00-17:00; Sat-Sun off. Exceptions (off unless hours are given): 2021-05-28 to 2050-05-27 08:00-12:00 (Friday Before Memorial Day, recurring), 2021-05-31 to 2050-05-30 (Memorial Day, recurring), 2021-07-03 to 2050-07-03 08:00-12:00 (Day before July 4th, recurring), 2021-07-04 to 2050-07-04 (July 4th, recurring), 2021-09-03 to 2050-09-02 08:00-12:00 (Friday Before Labor Day, recurring), 2021-09-06 to 2050-09-05 (Labor Day, recurring).
- Environmental/Seasonal Restrictions: Mon-Fri 08:00-12:00, 13:00-17:00; Sat-Sun off. Exceptions (off unless hours are given): 2021-03-01 to 2021-05-31 (Environmental Restriction 1), 2021-05-28 to 2050-05-27 08:00-12:00 (Friday Before Memorial Day, recurring), 2021-05-31 to 2050-05-30 (Memorial Day, recurring), 2021-07-03 to 2050-07-03 08:00-12:00 (Day before July 4th, recurring), 2021-07-04 to 2050-07-04 (July 4th, recurring), 2021-09-03 to 2050-09-02 08:00-12:00 (Friday Before Labor Day, recurring), 2021-09-06 to 2050-09-05 (Labor Day, recurring).
- Curing Calendar: Mon-Fri 08:00-12:00, 13:00-17:00; Sat-Sun 08:00-16:00.

## Schedule

| ID | WBS | Task | Type | Duration | Start | Finish | Predecessors | Total slack | Free slack | Constraint | Calendar | Text1 | Text2 |
| --- | --- | --- | --- | --- | --- | --- | --- | --- | --- | --- | --- | --- | --- |
| 1 | 1 | Pre Construction Meeting |  | 1d | 2021-02-01 | 2021-02-01 |  | 8d | 0d | start no earlier than 2021-02-01 |  | MEETING | MEETING/DAY |
| 2 | 2 | Notice to Proceed | milestone | 0d | 2021-02-01 | 2021-02-01 | 1 | 8d | 0d |  |  | NTP | NTP/DAY |
| 3 | 3 | Submit QC Plan |  | 1d | 2021-02-02 | 2021-02-02 | 2 | 163.5d | 0d |  |  | SUBMITTAL | SUBMITTAL/DAY |
| 4 | 4 | Review QC Plan |  | 5d | 2021-02-03 | 2021-02-09 | 3 | 163.5d |  |  |  | REVIEW | REVIEW/DAY |
| 5 | 5 | Submit SWPPP |  | 1d | 2021-02-02 | 2021-02-02 | 2 | 85.5d | 0d |  |  | SUBMITTAL | SUBMITTAL/DAY |
| 6 | 6 | Review SWPPP and submit NOI by contractor |  | 15d | 2021-02-03 | 2021-02-23 | 5 | 85.5d | 0d |  |  | REVIEW | REVIEW/DAY |
| 7 | 7 | **Build Roadway** |  | 169.5d | 2021-02-02 | 2021-09-29 |  | 0d |  |  |  |  |  |
| 8 | 7.1 | Mobilization |  | 14d | 2021-02-03 | 2021-02-22 | 2FS+1d | 86.5d | 1d |  |  | MOB | MOB/DAY |
| 9 | 7.2 | Verify FHWA Control |  | 1d | 2021-02-03 | 2021-02-03 | 2FS+1d | 8d | 0d |  | Environmental/Seasonal Restrictions | EA | EA/DAY |
| 10 | 7.3 | Topography Verification |  | 1d | 2021-02-04 | 2021-02-04 | 9 | 102d |  |  | Environmental/Seasonal Restrictions | EA | EA/DAY |
| 11 | 7.4 | Stake Centerline |  | 1d | 2021-02-04 | 2021-02-04 | 9 | 38d | 17d |  | Environmental/Seasonal Restrictions | LF | LF/DAY |
| 12 | 7.5 | Set Slope, Reference, Clearing Stakes |  | 1d | 2021-02-04 | 2021-02-04 | 9 | 8d | 0d |  | Environmental/Seasonal Restrictions | LF | LF/DAY |
| 13 | 7.6 | Survey MSE/Retaining Wall locations |  | 1d | 2021-02-05 | 2021-02-05 | 12 | 15d | 0d |  | Environmental/Seasonal Restrictions | EA | EA/DAY |
| 14 | 7.7 | MSE/Retaining Wall Site Designs |  | 10d | 2021-02-08 | 2021-02-19 | 13 | 74.5d | 0d |  |  | DESIGN | DESIGN/DAY |
| 15 | 7.8 | MSE/Retaining Wall Review |  | 10d | 2021-02-22 | 2021-03-05 | 14 | 74.5d | 59.5d |  |  | REVIEW | REVIEW/DAY |
| 16 | 7.9 | Precast Structures Submittal |  | 10d | 2021-02-02 | 2021-02-15 | 2 | 26.5d | 0d |  |  | SUBMITTAL | SUBMITTAL/DAY |
| 17 | 7.10 | Structures Review |  | 21d | 2021-02-16 | 2021-03-16 | 16 | 26.5d | 0d |  |  | REVIEW | REVIEW/DAY |
| 18 | 7.11 | Concrete Mix Design Submittal |  | 10d | 2021-02-02 | 2021-02-15 | 2 | 52.5d | 0d |  |  | SUBMITTAL | SUBMITTAL/DAY |
| 19 | 7.12 | Concrete Mix Design Review |  | 21d | 2021-02-16 | 2021-03-16 | 18 | 52.5d | 0d |  |  | REVIEW | REVIEW/DAY |
| 20 | 7.13 | Colored Concrete Panels Cast, Cure, and approve |  | 21d | 2021-03-17 | 2021-04-14 | 19, 18 | 73.5d |  |  |  | SAMPLE | SAMPLE/DAY |
| 21 | 7.14 | Asphalt Mix Design Submittal |  | 21d | 2021-02-02 | 2021-03-02 | 2 | 104.5d | 0d |  |  | SUBMITTAL | SUBMITTAL/DAY |
| 22 | 7.15 | Asphalt Mix Design Verification |  | 21d | 2021-03-03 | 2021-03-31 | 21 | 104.5d |  |  |  | REVIEW | REVIEW/DAY |
| 23 | 7.16 | Stone Masonry Sample Wall |  | 10d | 2021-02-02 | 2021-02-15 | 2 | 144.5d | 0d |  |  | SAMPLE | SAMPLE/DAY |
| 24 | 7.17 | Stone Masonry Review |  | 10d | 2021-02-16 | 2021-03-01 | 23 | 144.5d | 63.5d |  |  | REVIEW | REVIEW/DAY |
| 25 | 7.18 | Stone Masonry Installation |  | 5d | 2021-06-01 | 2021-06-07 | 24 | 81d |  |  | Environmental/Seasonal Restrictions | SF | SF/DAY |
| 26 | 7.19 | Cross Section drainage device for drainage plot |  | 2d | 2021-02-05 | 2021-02-08 | 12, 9 | 8d | 0d |  |  | EA | EA/DAY |
| 27 | 7.20 | Prepare Drainage Plots |  | 2d | 2021-02-09 | 2021-02-10 | 26SS+2d | 8d | 0d |  |  | EA | EA/DAY |
| 28 | 7.21 | Drainage Review |  | 7d | 2021-02-11 | 2021-02-19 | 27SS+2d | 8d | 0d |  |  | EA | EA/DAY |
| 29 | 7.22 | Stake Drainage structure/device |  | 2d | 2021-02-15 | 2021-02-16 | 28SS+2d | 8d | 5d |  | Environmental/Seasonal Restrictions | EA | EA/DAY |
| 30 | 7.23 | Delivery of Culverts and Appurtences |  | 10d | 2021-02-22 | 2021-03-05 | 28 | 90.5d | 0d |  |  | EA | EA/DAY |
| 31 | 7.24 | Fabrication and Delivery of Pre-cast structures |  | 21d | 2021-03-17 | 2021-04-14 | 17 | 35.5d | 31.5d |  |  | FABRICATION | FABRICATION/DAY |
| 32 | 7.25 | Fabrication and Delivery of Structural Plate Culverts |  | 30d | 2021-03-17 | 2021-04-27 | 17 | 26.5d | 22.5d |  |  | FABRICATION | FABRICATION/DAY |
| 33 | 7.26 | Install Erosion Control devices |  | 2d | 2021-02-24 | 2021-02-25 | 6, 8 | 21d | 0d |  | Environmental/Seasonal Restrictions | LF | LF/DAY |
| 34 | 7.27 | Clear and Grub |  | 2d | 2021-02-26 | 2021-06-01 | 33SS+2d | 21d | 0d |  | Environmental/Seasonal Restrictions | ACRE | ACRE/DAY |
| 35 | 7.28 | Removals of Structures and Obstructions |  | 1d | 2021-06-02 | 2021-06-02 | 34, 11 | 21d | 0d |  | Environmental/Seasonal Restrictions | LPSM | LPSM/DAY |
| 36 | 7.29 | Strip and stockpile top soil |  | 3d | 2021-06-03 | 2021-06-07 | 35 | 21d | 0d |  | Environmental/Seasonal Restrictions | CY | CY/DAY |
| 37 | 7.30 | Roadway Excavation and Embankment Construction |  | 10d | 2021-06-08 | 2021-06-21 | 36 | 21d | 0d |  | Environmental/Seasonal Restrictions | CY | CY/DAY |
| 38 | 7.31 | Subexcavation |  | 2d | 2021-06-08 | 2021-06-09 | 36 | 43d | 8d |  | Environmental/Seasonal Restrictions | CY | CY/DAY |
| 39 | 7.32 | Subgrade Stabilization |  | 2d | 2021-06-22 | 2021-06-23 | 37, 38 | 35d | 25d |  | Environmental/Seasonal Restrictions | SY | SY/DAY |
| 40 | 7.33 | Install Underdrain |  | 2d | 2021-06-08 | 2021-06-09 | 36 | 31d | 14d |  | Environmental/Seasonal Restrictions | LF | LF/DAY |
| 41 | 7.34 | Roadway Obliteration |  | 5d | 2021-06-24 | 2021-06-30 | 37FS+2d | 59d | 0d |  | Environmental/Seasonal Restrictions | SY | SY/DAY |
| 42 | 7.35 | Place conserved topsoil |  | 2d | 2021-06-28 | 2021-06-29 | 37SS+2d, 41SS+2d | 60d | 31d |  | Environmental/Seasonal Restrictions | CY | CY/DAY |
| 43 | 7.36 | Install Culvert and End Sections |  | 2d | 2021-02-24 | 2021-02-25 | 29, 30SS+2d | 26d | 22d |  | Environmental/Seasonal Restrictions | EA | EA/DAY |
| 44 | 7.37 | Install Precast or Structural Plate structures |  | 21d | 2021-06-01 | 2021-06-29 | 31, 32 | 4d | 0d |  | Environmental/Seasonal Restrictions | LF | LF/DAY |
| 45 | 7.38 | Install cast in place box culverts |  | 25d | 2021-06-01 | 2021-07-05 | 29, 19 | 0d |  |  | Environmental/Seasonal Restrictions | LF | LF/DAY |
| 46 | 7.39 | Install Headwalls and Wingwalls including backfill (each side) |  | 15d | 2021-07-05 | 2021-07-26 | 43, 45, 44, 19 | 0d |  |  | Environmental/Seasonal Restrictions | SF | SF/DAY |
| 47 | 7.40 | MSE/Retaining Wall Design and Delivery |  | 15d | 2021-06-01 | 2021-06-21 | 15 | 15d | 0d |  | Environmental/Seasonal Restrictions | FABRICATION | FABRICATION/DAY |
| 48 | 7.41 | Installation of MSE/Retaining Wall Components |  | 10d | 2021-06-22 | 2021-07-05 | 47 | 15d |  |  | Environmental/Seasonal Restrictions | SF | SF/DAY |
| 49 | 7.42 | Stake Approach Roads, Curbs, Sidewalks, Pullouts, Parking Areas |  | 2d | 2021-06-22 | 2021-06-23 | 37, 9 | 21d | 4d |  | Environmental/Seasonal Restrictions | EA | EA/DAY |
| 50 | 7.43 | Riprap - Lined Ditches / Culvert aprons/ gabions / Special rock Embankment |  | 1d | 2021-07-26 | 2021-07-27 | 43, 37, 46 | 40d | 11d |  | Environmental/Seasonal Restrictions | CY | CY/DAY |
| 51 | 7.44 | Grade Finishing Stakes (Red Tops) |  | 2d | 2021-06-30 | 2021-07-01 | 37, 43, 44, 40, 49 | 17d |  |  | Environmental/Seasonal Restrictions | LF | LF/DAY |
| 52 | 7.45 | Finish Subgrade |  | 2d | 2021-07-26 | 2021-07-28 | 51, 43, 48, 46 | 0d |  |  | Environmental/Seasonal Restrictions | LF | LF/DAY |
| 53 | 7.46 | Install Curb (concrete, asphalt, stone) |  | 5d | 2021-07-28 | 2021-08-04 | 52, 20 | 0d |  |  | Environmental/Seasonal Restrictions | LF | LF/DAY |
| 54 | 7.47 | Install Sidewalks (concrete or asphalt) |  | 10d | 2021-07-28 | 2021-08-11 | 53SS, 20 | 0d |  |  | Environmental/Seasonal Restrictions | SY | SY/DAY |
| 55 | 7.48 | Place Aggregate Base |  | 3d | 2021-08-11 | 2021-08-16 | 54, 52 | 0d |  |  | Environmental/Seasonal Restrictions | TONS | TONS/DAY |
| 56 | 7.49 | Cement Treated Base (3R) |  | 3d | 2021-07-28 | 2021-08-02 | 39, 52 | 10d |  |  | Environmental/Seasonal Restrictions | SY | SY/DAY |
| 57 | 7.50 | Grade Finishing Stakes (Blue Tops) |  | 2d | 2021-08-16 | 2021-08-18 | 56, 55 | 0d |  |  | Environmental/Seasonal Restrictions | LF | LF/DAY |
| 58 | 7.51 | Finish Aggregate Base Course |  | 2d | 2021-08-18 | 2021-08-20 | 57 | 0d |  |  | Environmental/Seasonal Restrictions | LF | LF/DAY |
| 59 | 7.52 | Install Guardrail |  | 4d | 2021-06-03 | 2021-06-08 | 35 | 80d |  |  | Environmental/Seasonal Restrictions | LF | LF/DAY |
| 60 | 7.53 | Recycling, Cold-in-place |  | 2d | 2021-06-03 | 2021-06-04 | 35 | 82d |  |  | Environmental/Seasonal Restrictions | SY | SY/DAY |
| 61 | 7.54 | Asphalt Pavement Milling or Pulverizing |  | 2d | 2021-06-03 | 2021-06-04 | 35 | 55d |  |  | Environmental/Seasonal Restrictions | SY | SY/DAY |
| 62 | 7.55 | Prime Coat and Cure |  | 4d | 2021-08-20 | 2021-08-26 | 61, 58 | 0d |  |  | Environmental/Seasonal Restrictions | SY | SY/DAY |
| 63 | 7.56 | Asphalt Test Strip |  | 10d | 2021-08-26 | 2021-09-10 | 22, 62, 57, 58 | 0d |  |  | Environmental/Seasonal Restrictions | EA | EA/DAY |
| 64 | 7.57 | Asphalt Paving |  | 2d | 2021-09-16 | 2021-09-17 | 63FS+3d | 0d |  |  | Environmental/Seasonal Restrictions | TONS | TONS/DAY |
| 65 | 7.58 | Asphalt Surface Treatment (fog seal) |  | 2d | 2021-09-20 | 2021-09-21 | 64 | 0d |  |  | Environmental/Seasonal Restrictions | SY | SY/DAY |
| 66 | 7.59 | Pavement marking |  | 1d | 2021-09-22 | 2021-09-22 | 65 | 0d |  |  | Environmental/Seasonal Restrictions | LF | LF/DAY |
| 67 | 7.60 | Sign and Delineator Installation |  | 2d | 2021-07-28 | 2021-07-30 | 52 | 39d |  |  | Environmental/Seasonal Restrictions | EA | EA/DAY |
| 68 | 7.61 | Seeding, Mulching, Matting |  | 2d | 2021-08-11 | 2021-08-13 | 41, 54, 42, 50 | 29d |  |  | Environmental/Seasonal Restrictions | ACRE | ACRE/DAY |
| 69 | 7.62 | Weather Delays to Critical Path |  | 2d | 2021-09-23 | 2021-09-24 | 66 | 0d |  |  | Environmental/Seasonal Restrictions | EA | EA/DAY |
| 70 | 7.63 | Clean Up |  | 2d | 2021-09-27 | 2021-09-28 | 69, 67, 68 | 0d |  |  | Environmental/Seasonal Restrictions | EA | EA/DAY |

Notes:
- 3: We ask for this to be presented at the Preconstruction meeting. Sometimes it is given to us, and sometimes it is not completed. However, for scheduling purposes, since we ask for it at the Precon, we use a 1 day duration. If there is a delayed notice to proceed anticipated for the project, ie project awarded during winter, but precon held early so that the contractor can start crushing, getting submittals completed, ordering materials, etc, this may be scheduled later.
- 4: Depending on the complexity of the project, this may take a shorter or longer time than is shown. The project engineer will normally finsih reviewing within a couple days, however often they require additional information from the Contractor, so the 5 days allows for the exchange of information.
- 5: On projects where CFL has prepared a preliminary SWPPP, it may only take a couple of days for the contractor to finish it and get it approved. On projects where a SWPPP is not prepared ahead of time, it will take some time to put it together for most projects. The contractor has to have it complete and approved prior to starting ground disturbing activities and most states require that they have issued an acknowledgement letter that the NOI is submitted.
- 6: States and the EPA vary greatly on how long it takes to get approval to be covered by the Construction General Permit (CGP). Projects on lands where the EPA is the permitting authority, the time frame is about 7 days from receipt of the NOI if filed electronically. The CGP will normally indicate approval timeframes. Projects near unique or impaired waters will almost always take longer and have special conditions to meet.
- 7: Break this summary down into shorter segments or phases for projects with multiple roads, heavy reconstruction, lots of walls, etc. Also use segments or phases if the contract is going to require one phase to be completed before another phase begins.
- 8: Typical Production Rates/ High: 22 days - large projects; large earthwork quantities; rock excavation; multiple and/or large structures / Average: 10 days - paving and grading projects with minimal earthwork / Low: 3 days - use on smaller projects with minimal scope
- 9: Surveyor has to do this first to find the T-Points and verify locations and elevations. Depends on the length of the project for how long it takes. Generally if CFL has staked the project during design, the T-Points are fairly accessible. If the control is old, it will take longer. Generally about 2 miles per day can be verified in hilly terrain and flatter terrain. Mountainous steeper terain may only get 1 mile per day.
- 10: This item will only be needed if it is a requirement on the project and there is a time frame that they have to submit the information to the CO prior to doing slope stakes or prior to starting construction.
- 11: This activity is applicable on projects where limited survey data is provided to the contractor and centerline staking is required prior to any ground breaking activity / Typical Production Rates/ Low = 1600 LF/day / Medium = 3200 LF/day / High = 4800 LF/day
- 12: Typical Production Rates/ ·Low production for steep terrain, forested, close intervals, unusual circumstances: 400 LF to 600 LF/day / ·Average production: 800 LF to 1000 LF/day / ·High production when flat terrain, not much vegetation or obstacles: up to 1600 LF/day / These production rates represent LNFT of Roadway Centerline (ie: assuming contractor stakes BOTH Lt. and Rt. slopes).
- 13: ·This task production will depend on terrain, length of walls etc. and how thorough the preliminary survey was for the design in the plans. / ·Allow at least one day per wall location. / ·Depending on the project size and scope, this may be done later in the project once other earthwork has begun; however, either way the contractor will want to get started on this task concurrently with other earthwork items.
- 14: ·This activity generally takes at least couple of weeks for the contractor to get the survey data, verify everything, and then finish the design of the wall and submit the shop drawings for approval. / ·Some walls will require more detail in the shop drawings, so more time may be needed here.
- 15: ·This task will be based on the language in the contract for the amount of time the Government requires to review the shop drawings. / ·Adjust to match the maximum days we require.
- 16: ·This activity generally takes at least couple of weeks for the contractor to get the survey data, verify everything, and then finish the design of the structure and submit the shop drawings for approval.
- 17: ·This task will be based on the language in the contract for the amount of time the Government requires to review the shop drawings. Adjust to match the maximum days we require.
- 18: This task may take several weeks if the contractor has to do a new mix design for the project. If they can use prior mix designs that they have historical data on, then it doesn't take as long. Colored concrete mix designs may cause longer durations to submit the mix. / If the concrete on the project is 601 concrete, then this duration can be shorter, because the submittal doesn't require as much data. If it is a structure, then provide more time in the schedule to receive the submittal.
- 19: ·This task will be based on the language in the contract for the amount of time the Government requires to review the shop drawings. / ·Adjust to match the maximum days we require.
- 20: ·This process can take up to a month to get the panels cast, allow the required cure time and give the owner agency time to approve the color. / ·The SCR's will probably have some time frames that need to be taken into account.
- 21: From the time the contract is awarded until the contractor can get samples to an independent lab to design the asphalt mix is generally a couple of months. For contract scheduling purposes, allow at least one month from NTP to get this data from the contractor. If the probable source of the aggregates is not a commercial source and crushing has to be done, the time frame is longer because enough crushing production has to be done for the contractor to pick possible target values to base the mix design on. This task is especially important to consider on projects that are mostly paving, with little other construction work to be done ahead of the paving. / The mix design process from the time the contractor has material crushed until the mix design is approved in Denver is a minimum of 2 months.
- 22: This task will be based on the language in the contract for the amount of time the Government requires to review the mix design. Adjust to match the maximum days we require. This item creates a stumbling block too often in construction becasue the contractor doesn't allow enough time for a failed submittal.
- 23: ·There isn't much data available for this, but allow the contractor enough time to build the wall according to what is in the SCR's. / ·If there is staining involved, allow for the cure time also.
- 24: ·This task will be based on the language in the contract for the amount of time the Government requires to review the shop drawings or the sample wall. / · Adjust to match the maximum days we require.
- 25: Rates from RS Means:/ Low = 35 SQFT/day / Average = 50 SQFT/day / High = 100 SQFT/day / Rates include excavation and are based on exposed wall face area
- 26: The surveyors should be able to do several locations a day, depending on terrain. / ·In easy terrain, assume 8 locations a day. / ·For rough terrain and/or wide spread locations, assume 2 to 3 locations per day. / ·Often, they will have to relocate base stations between different locations, which significantly reduces production rate
- 27: ·If we are providing plots in the cross sections of the plans, then the surveyor may be able to provide plots for approval within a couple of days. / ·If they have to start with the field data, then it takes longer. This work quite often goes back to the surveyor's office to be done, so the turn around time is longer. / ·They should be able to do 2 plots per day at least, but the first plot might take 5 days from when the survey is completed.
- 28: This task will be based on the language in the contract for the amount of time the Government requires to review the shop drawings. Adjust to match the maximum days we require.
- 29: Surveyor can probably stake about double the amount of culverts that they can cross section in a day because the reference stakes should already be in place and all they have to do is put the information on them.
- 30: ·Culverts up to 36 inches are normally readily available to ship from suppliers if there are no special coatings or appurtenances that have to go with them. / ·Culverts larger than 36 inch may have to be made to supply the project and a supplier normally will run different sizes one size at a time for a few days and then move on to the next size. / ·Larger culverts take up more room on a truck, so not nearly as many pieces can be shipped at once. / ·If there are arch pipe specified, it will take longer to get because it isn't a stock item. / ·Allow 10 working days for the culverts up to 36" in diameter. Allow a month for bigger sizes and arch pipes unless there are a lot of smaller round pipes and just a few big pipes that can be placed when the pipe gets there and are not so critical. / ·Specialty pipes will need a longer lead time.
- 31: ·This is at least 2 weeks unless it is something that a pre-caster has in stock. / ·Normally at least a month will be needed for fabrication, after all submittals have been approved. The supplier will have to set forms, tie reinforcement, prestress as necessary, place the concrete and then allow time for curing prior to shipment. / ·On special sizes, shapes, larger boxes, allow longer than a month because the pieces have to be made and shipped one or 2 at a time.
- 32: These structures are fabricated according to the approved drawings and quite often take at least 6 weeks to ship. Consider project specific structure for appropriate duratio for fabrication and delivery.
- 33: Consider BMPs that need to be installed before the work can begin, specifically perimeter controls (silt fence, etc...), BMPs to keep offsite water away from the construction area, etc. Normally, the disturbance of the project can start once the SWPPP has been implemented. / Production rates for Silt Fence/ ·Low = 200 LF/day / ·Average = 1000 LF/day / ·High = 1700 LF/day / ·Use lower rates if terrain is rocky, steep, hard to access.
- 34: Production rates vary depending on terrain, trees and brush to be removed, and amount of rock/boulders to be worked around. / The size of the project in acres will affect this as small projects will just bring in minimal equipment to do the clearing and grubbing and big projects will bring what they need to do the project efficiently. / ·Low production rates range from 0.3 Acres per day for lots of large trees, rugged terrain, and or heavy brush to 1.3 acre per day on projects with few tress, flatter terrain, and less brush. Use on smaller projects. / ·Average production rates range from 1.3 acres per day to 3 acres per day. / ·High production rates range from 2.7 acres per day with lots of trees and rugged terrain to 6 acres per day for flatter terrain and not too many trees.
- 35: Typical Production Rates Low Avg High / ·PCC pavement by SY - 500 1000 2500 Reduce rate, as depth increases and quantity decreases / ·Asphalt pavement by SY 500 3500 7500 Reduce rate, as depth increase and quantity decreases / ·Concrete curb and gutter by LF 200 360 1100 / ·Sidewalk by SY 100 600 1200 / ·Guardrail by LF 310 600 870 / ·Pipe, < 36" diameter by LF 120 250 360 use installation rate (no removal) for replacement of existing pipe / ·Pipe, 36" and greater by LF 95 150 270 use installation rate (no removal) for replacement of existing pipe / ·Pavement cutting (AC) by LF 800 1600 2400 reduce rate as depth increases / ·Pavement cutting (PCC) by LF 800 1600 2400 reduce rate as depth increases / ·Major Structures by days/EA 1 3 10 Rate is highly dependent on type and dimensions of structures / ·Minor Structures by EA/day 5 10 20 Rate is highly dependent on type and dimensions of structures
- 36: Lower production rates should be used when excessive boulders and steep terrain are encountered and on smaller projects. Higher production rates can be used on projects of substantial size and where the terrain is moderate. / Typical Production Rates/ Low: 50 CY/day / Average: 150 CY/day / High: 450 CY/day
- 37: There are a number of factors to take into account for this item. See the list of factors at the bottom of this note that should be used to adjust your base number, as appropriate. / Excavation: less than 50,000 cy of excavation or a haul distance of 5 miles / ·Low = 400 CY/day / ·Average = 1600 CY/day / ·High = 2500 CY/day / Excavation: over 50,000 cy of excavation / ·Low = 1200 CY/day / ·Average = 2800 CY/day / ·High = 4500 CY/day / Embankment: for project with a good excavation/embankment balance, rates normally mirror excavation rates / ·Low = 250 CY/day / ·Average = 1100 CY/day / ·High = 3000 CY/day / ·Projects with significant borrow should consider likely haul distance as this may likely be a controlling factor / Excavation: Rippable rock / ·Low = 300 CY/day / ·Average = 900 CY/day / ·High = 1500 CY/day / ·Consdier project specific rock structure and strength / ·Quantity of rippable rock will dictate the size and type equipment that the contractor uses / ·Most rock can be ripped by a D8 bulldozer or a large excavator with rock teeth, but a D10 has a lot more power, so on big jobs, the contractor will bring in the bigger, more powerful equipment that will yield higher production rates. / Rock to be blasted has production rates of / ·Low = 150 CY/day, / ·Average = 250 CY/day / ·High = 400 CY/day / ·Reduce rate for difficult accessibility / ·Site quantity and dimensions, traffic requirements, and material hardness will impact the quantity of each shot and therefore the total production time; multiple sites will reduce production rate / Adjustment factors that affect the production rates (from a TXDOT study; use a max. of 2 adjustment factors): / ·Location: Rural = 1.0, Small City = 0.85, and Large City = 0.75 / ·Traffic Conditions: Light = 1.0, Moderate = 0.88 and High = 0.70 / ·Complexity: Low = 1.0, Medium = 0.85 and High = 0.70 / ·Quantity of Work: Large 1.0, Medium, 0.88 and Small 0.75 / ·Soil Conditions: Good = 1.0, Fair = 0.85, Poor = 0.65 Good soils would be A-1 and A3. Fair are A2, A4, and A5 soils. / ·Poor soils would be A6 and A7 soils.
- 38: Typical Production Rates where No Shoring or Dewatering are required: / 1 to 5 feet depth - as quantity and work area increase - production rates will increase. / ·Low = 125 CY/day / ·Average = 325 CY/day / ·High = 500 CY/day / 5 to 10 feet depth / ·Low = 225 CY/day / ·Medium = 600 CY/day / ·High = 1000 CY/day / Add time for installation of dewatering efforts as required
- 39: Increase rate with larger work areas. Reduce rate as depth increases. There are 3 types of subgrade stabilization listed in the chart, but only 2 that CFL uses often. These activities may also need to be sequenced one lane at a time if the road cannot be closed. Mixing machines are normally 8 feet wide, and there is normally a 1 foot overlap between passes. The data below is for a typical 6-8 inch depth. / Production rates are Low Average High / Cement 900 SY 4000 SY 5000 SY / Lime 900 SY 4000 SY 6000 SY / Asphalt 900 SY 3000 SY / Limited information available for asphalt subgrade stabilization. / Add necessary curing time for lime and cement stabilization.
- 40: Typical Production Rates/ Low = 200 LF/day / Average = 400 LF/day / High = 800 LF/day / Reduce rates for rocky soil, smaller quantities and larger trench dimensions
- 41: Normally the contractor will do obliteration in conjunction with earthwork and placing topsoil, so this task will not normally be on the critical path. Rates will vary depending on how much work is required to return it to the original condition. Large areas with simple horizontal and veritcal geometry will have a production rate up to 2000 SY/day. Areas that require additional fill or projects with multiple small obliteration sites will have lower production rates.
- 42: Typical Production Rates/ Low: 200 CY/day for low production, small projects / Average: 800 CY/day for average production / High: 1200 CY/day for high production large projects. / Rates include shaping and compacting/tracking the topsoil
- 43: ·Assume one installation per day per crew in most cases for pipe under 48" diameter. / ·Increase installation rate for shallow installation, short lengths and/or pipe diameters over 48" / ·Reduce installation rate for pipes over 5 feet deep at centerline or over 100 feet in length / ·Consider traffic passage requirements. Contractors typically install 1/2 pipe length at a time / ·Consider subgrade material type; reduce rate for rocky soil where extended excavation time will be required / ·When headwalls are required on pipes, add a headwall/wingall installation as a seperate task. / ·Larger quantities of pipe on a project may results in more than one pipe crew, resulting in an increase in overall production
- 44: Typical Precast installation rates/ Low: 15 LF/day / Average: 70 LF/day / High: 140 LF/day / ·Rates do not include excavation, backfill, off-site fabrication and transportation to the project; these tasks should be added to the total duration and or added as a separate task / ·Site specific conditions should be considered; these include: structure size, and traffic passage requirements / ·Structural Plate culverts can be assembled outside the excavation and swung into place once the excavation is ready. A crew can assemble about 20 LF feet per day. Assume 2-3 days for installation per 1/2 culvert installation.
- 45: Typical Production Rates / Low: 2 LF/day / Average: 10 LF/day / High: 16 LF/day / ·Rates include forming, tieing, concrete pour and stripping forms but do not include excavation or backfill. / ·Site specific conditions (box size, traffic passage requirements, existing structure removal, soil type, dewatering, etc...) should be considered.
- 46: Typical Production Rates/ ·Low = 14 SF/day, / ·average = 35 SF/day, and / ·high = 90 SF/day. / ·Add 7 work days for curing and backfill / Note: on our projects, the headwalls and wingwalls are typically fairly small in area, but still take time to form, reinforce, pour (f/r/p), strip and cure before backfill. Depending on traffic passage requirements, and site dimensions (culvert depth, etc), the contractor may work on both ends of a culvert simultaneously, so the lag time between ends may be 1- 2 days to start to start. / Alternatively, the designer may use the following method for duration determination for Headwalls/Wingwalls for pipes 48" diameter to 84" diameter where headwall and wingwall can be placed at the same time: / ·Excavate and f/r/p footers for headwalls and wingwalls - 2 - 3 days per wall average / ·f/r/p headwall and wingwalls - 3 to 5 days average (depends on size of wall and accessibility) / ·Cure 7 calendar days from last concrete placement / ·Backfill 1-2 days. / ·Rate is dependent on type and dimensions of structures
- 47: This task depends on the size, type and dimensions of wall that is specified. This task requires the seal of a PE; assume design will take a minimum of one week (longer for larger structures). The availability of specific materials will determine delivery lead time. Wire faced walls usually ship fairly quickly; depending on geographic location, block walls may take longer. Prior to specifying a type of material, it is recommended that the Designer contact local suppliers to confirm material availability, lead time, assumed production rates, etc.
- 48: Typical Production Rates Low Medium High / ·MSE Wall footings or leveling pads 68 LF 178 LF 300 LF Add some cure time if concrete / ·MSE, Block walls 500 SF 750 SF 1300 SF Lower rates by 5% for small blocks / ·MSE Wall 40 SF 150 SF 220 SF As wall size and area increases, / increase production rate. / ·MSE Wall with copings 150 LF 285 LF 355 LF As length of coping increases, / increase production rate / ·Rienforced Concrete Retaining walls 100 SF 150 SF 200 SF May need to add days for cure / time prior to backfilling Lower / rates if formliner is to be used. / ·Stone masonry guardwalls or 150 SF Limited data available, this is in / stone facing on retaining walls addition to the concrete portions / of the walls
- 49: Only include this item if there are significant amounts of extra staking to be done. Major approach roads, pullouts with curbs, sidewalk, or other special features, and larger parking areas take time to stake and grade. Minor approaches, pullouts, etc will just be staked as the surveyor stakes the mainline normally. Allow 1 to 2 days for each area, depending on complexity.
- 50: Riprap aprons at small culverts are generally done with the culvert or shortly thereafter and do not need to be added as a separate task on the CPM. / Larger riprap aprons, settlement basins, etc. / ·Low = 20 CY/day, / ·Average = 40 CY/day / ·High = 60 CY/day / Riprap lined ditches / ·Low = 100 LF/day / ·Average = 200 LF/day / ·High = 300 LF/day / Gabions / ·Low = 40 CY/day, / ·Average = 300 CY/day, / ·High = 600 CY/day / ·Increase production rates as quantity, and size of structure increase. / Special Rock Embankment (mechanically placed)/ ·Low = 75 CY/day, / ·Average = 180 CY/day, / ·High = 280 CY/day. / ·Consider accessibility, slope steepness, quantity and haul distance
- 51: Typical Production Rates/ ·Low = 800 LF/day, / ·Average = 1600 LF/day, / ·High = 2400 LF/day / Use lower rates for smaller projects, stiff/rocky soils and steep vertical alignments
- 52: Typical Production Rates/ ·Low = 500 LF/day, / ·Average = 1000 LF/day, / ·High = 2000 LF/day. / ·These rates do not include survey (red tops) / ·Increase production rate if machine guidance is expected / ·Decrease production rate for rocky/stiff subgrade
- 53: Concrete Curb and Gutter or Curb w/o gutters - Machine placed/ ·Low = 160 LF/day, / ·Average = 480 LF/day, / ·High = 900 LF/day / ·Reduce rates for hand placed C&G / Asphalt curb/ ·Low = 650 LF/day, / ·Average = 1200 LF/day, / ·High = 1850 LF/day. / Stone Curb/ ·Low: 50 LF/day / ·Average = 100 LF/day / ·High = 150 LF/day / ·This information was based on limited data available and will vary based on stone dimensions
- 54: Asphalt sidewalks/ ·From RS Means / ·2" thick = 720 SY/day / ·2 1/2" thick = 660 SY/day / ·Reduce rates for increased hand work and radii in sidewalk / Concrete Sidewalks/ ·Low: 80 SY/day / ·Average: 160 SY/day / ·High: 280 SY/day / ADA accessible ramps / ·Low = 12 SY/day, / ·Average = 22 SY/day, / ·High = 30 SY/day.
- 55: Typical Production Rates/ ·Low = 400 tons/day, / ·Average =1000 tons/day, / ·High = 1800 tons/day. / Factors to take into account are how far is the haul, the quantity to be placed, and terrain of haul roads. Projects with relatively flat terrains and short hauls will exceed the 1800 tons per day. Steep terrain and long hauls will normally be in the average range shown.
- 56: Typical Production Rates/ ·Low = 900 SY/day, / ·Average = 4000 SY/day, / ·High = 6000 SY/day / Factors to consider in choosing rate are / ·traffic passage and/or road closure options / ·size of the work area, / ·curing time required prior to placing adjacent lane or cover course.
- 57: Typical Production Rates/ ·Low = 800 LF/day/ ·Average = 1600 LF/day / ·High = 2400 LF/day / ·Use lower rates for smaller projects and on projects within steep topography / ·rates represent one course of aggregate (ie: red tops, blue tops, etc) / ·include time for survey of each aggregate course
- 58: Typical Production Rates/ ·Low = 500 LF/day / ·Average = 1000 LF/day / ·High = 2000 LF/day / ·Increase rates if machine guidance is anticipated (ie: larger linear projects)
- 59: Typical Rates based on type of guardrail being installed. All units are LF per day / Low Medium High / ·W-Beam or Box-Beam 250 500 1000/ ·Timber backed 600 Limited data available / ·Cable guardrail 800 Limited data available
- 60: Typical Production Rates/ ·Average production = 12000 SY/day (limited EEBACS data available) / ·This is about 1.7 miles per day for a 12 ft lane / ·RS Means gives a rate of 2000 to 2400 SY per day, but does not verify historic EEBACS data / Take into account: / ·Depth of recycled material, / ·roadway geometry / ·size and length of work area, / ·traffic requirements through the work area.
- 61: Typical Pavement Milling and Removal Rates/ ·Low = 2000 SY/day / ·Average = 3000 SY/day / ·High = 6500 SY/day / Typical rates: Pavement Pulverization, remaining in place/ ·Low =2000 SY/day / ·Average = 4000 SY/day / ·High = 12500 SY/day. / ·Rates assume 3" thick asphalt, and 6" pulverization depth / ·Reduce rates for thicker apshalt and deeper pulverization
- 62: Typical Production Rates/ ·Low = 3900 SY/day, / ·Average = 10,000 SY/.day, / ·High = 20,000 SY/day. / ·Larger linear projects will generally have higher production rates / ·For smaller quantities, be sure to allow for cure time prior to placing the next course of material
- 63: This is a 1 day production activity and then several working days to evaluate the results. Include a minimum of 2 days for shipping samples to the FHWA lab. Assume a minimum of 6 days for laydown, shipping, testing and reporting. Each test strip takes 7-10 days total.
- 64: Typical Production Rates/ ·Low = 550 TON/day / ·Average = 1000 TON/day / ·High = 1700 TON/day / Factors that need to be considered: / ·Item quantity / ·Haul distance from plant / ·Traffic requirements through work area (road closure avaiable?) / ·Paving complexity (ie: relatively constant width/depth? curve widening? paved pullouts? paved ditches?)
- 65: Fog Seal/ ·Low = 3 TON/day / ·Average = 5 TON/day / ·High = 7 TON/day / Chip Seal/ ·Low = 2500 SY/day, / ·Average = 13500 SY/day, / ·High = 21000 SY/day. / ·Allow at least one extra day to broom / ·may also require additional cure time
- 66: Typical Mainline Rates/ ·Low = 20,000 LF/day / ·Average = 50,000 LF/day / ·High = 85,000 LF/day. / ·these rates are for a single coat / Typical Parking Lot Rates/ ·rate depends on size of parking lot / ·layout may take up to a couple days for large lots / ·striping will usually take one day / Symbols/ ·Low = 5 EA/day / ·Average = 10 EA/day / ·High = 18 EA/day / Pavement Marking with Thermoplastic/ ·Low = 3,100 LF/day / ·Average = 5,600 LF/day / ·High = 10,000 LF/day
- 67: Sign installation/ ·Low = 10 each/day / ·Average = 20 each/day / ·High = 30 each/day / ·Reduce rates if soil is stiff/rocky / Delineator installation/ ·Low = 35 each/day, / ·Average = 50 each/day / ·High = 100 each/day
- 68: Hydraulic seeding and mulching/ ·Low = 2.5 Acres/day / ·Average = 8 acres/day / ·High = 11 acres/day / ·Hydro-seeding and hydro-mulch have the same rates and are applied simultaneously
- 69: Look at weather patterns for the project. If there are periods of high precipitation that is likely to delay work, some days need to be added to the schedule to account for lost production time. The contractor will/should use weather data from the previous 10 years to determine appropriate weatehr delays to build into their schedule. Our schedule should include the same assumption in order to assure adequate contract time. / The amount of precipitation within a given 24 hour period that causes lost production time will vary depending on the type of soils in the area.
- 70: Typical Production Rates/ ·Low = 10 STA/day / ·Average = 30 STA/day / ·High = 50 STA/day

| ID | WBS | Task | Duration | Start | Finish | Predecessors | Total slack | Free slack | Calendar | Text1 | Text2 |
| --- | --- | --- | --- | --- | --- | --- | --- | --- | --- | --- | --- |
| 71 | 7.64 | Final Inspection | 1d | 2021-09-29 | 2021-09-29 | 70 | 0d |  | Environmental/Seasonal Restrictions | EA | EA/DAY |
| 72 | 8 | **Bridge Items** | 68.5d | 2021-02-02 | 2021-08-06 |  | 31d |  | Environmental/Seasonal Restrictions |  |  |
| 73 | 8.1 | Review Bridge Submittals | 25d | 2021-02-02 | 2021-03-08 | 2 | 95.5d | 58.5d |  | REVIEW | REVIEW/DAY |
| 74 | 8.2 | Bridge survey | 2d | 2021-06-01 | 2021-06-02 | 9, 73 | 37d | 0d | Environmental/Seasonal Restrictions | LPSM | LPSM/DAY |
| 75 | 8.3 | Dewatering | 2d | 2021-06-03 | 2021-06-04 | 73, 74 | 37d | 0d | Environmental/Seasonal Restrictions | LPSM | LPSM/DAY |
| 76 | 8.4 | Traffic Diversion Installation | 2d | 2021-06-07 | 2021-06-08 | 75 | 37d | 0d | Environmental/Seasonal Restrictions | LPSM | LPSM/DAY |
| 77 | 8.5 | Remove existing Structure | 5d | 2021-06-09 | 2021-06-15 | 76 | 37d | 0d | Environmental/Seasonal Restrictions | SF | SF/DAY |
| 78 | 8.6 | Drilled Shafts | 3d | 2021-06-16 | 2021-06-18 | 74, 77 | 37d | 0d | Environmental/Seasonal Restrictions | LF | LF/DAY |
| 79 | 8.7 | Piles, Driving concrete | 3d | 2021-06-16 | 2021-06-18 | 74, 77 | 37d | 0d | Environmental/Seasonal Restrictions | LF | LF/DAY |
| 80 | 8.8 | Piles Driving Steel | 3d | 2021-06-16 | 2021-06-18 | 74, 77 | 37d | 0d | Environmental/Seasonal Restrictions | LF | LF/DAY |
| 81 | 8.9 | Forms & Reinforcement (Substructure) | 3d | 2021-06-21 | 2021-06-23 | 78, 79, 80 | 37d | 0d | Environmental/Seasonal Restrictions | LBS | LBS/DAY |
| 82 | 8.10 | Structural Concrete (Substructure) | 5d | 2021-06-24 | 2021-06-30 | 81 | 37d | 0d | Environmental/Seasonal Restrictions | CY | CY/DAY |
| 83 | 8.11 | Cure Structural Concrete (Substructure) | 7d | 2021-07-01 | 2021-07-07 | 82 | 50.5d | 0d | Curing Calendar |  | DAY |
| 84 | 8.12 | Set Girders | 2d | 2021-07-08 | 2021-07-09 | 83 | 36.5d | 0d | Environmental/Seasonal Restrictions | EA | EA/DAY |
| 85 | 8.13 | Structural Steel Beams | 2d | 2021-07-01 | 2021-07-02 | 82 | 42d | 5.5d | Environmental/Seasonal Restrictions | EA | EA/DAY |
| 86 | 8.14 | Forms & Reinforcement (Superstructure) | 2d | 2021-07-12 | 2021-07-13 | 85, 84 | 36.5d | 0d | Environmental/Seasonal Restrictions | LBS | LBS/DAY |
| 87 | 8.15 | Deck Survey | 1d | 2021-07-14 | 2021-07-14 | 86 | 36.5d | 0d | Environmental/Seasonal Restrictions | LPSM | LPSM/DAY |
| 88 | 8.16 | Structural Concrete (Superstructure) | 2d | 2021-07-15 | 2021-07-16 | 87 | 36.5d | 0d | Environmental/Seasonal Restrictions | CY | CY/DAY |
| 89 | 8.17 | Sidewalks and Parapets | 2d | 2021-07-19 | 2021-07-20 | 88 | 49.5d |  | Environmental/Seasonal Restrictions | SPANS | SPANS/DAY |
| 90 | 8.18 | Wingwalls and Retaining Walls | 2d | 2021-07-14 | 2021-07-15 | 86 | 52.5d |  | Environmental/Seasonal Restrictions | SF | SF/DAY |
| 91 | 8.19 | Deck Grooving | 1d | 2021-08-06 | 2021-08-06 | 88FS+14d | 36.5d |  | Environmental/Seasonal Restrictions | SF | SF/DAY |
| 92 | 8.20 | Membrane Waterproofing | 1d | 2021-08-06 | 2021-08-06 | 88FS+14d | 36.5d |  | Environmental/Seasonal Restrictions | LF | LF/DAY |

Notes:
- 71: ·Typically one day / ·Depending on project size, and/or travel time between sites/options, this item may be more than one day
- 72: These are the major tasks to be scheduled for a bridge. Select the tasks that apply to your project. The durations shown are not accurate. Production rates are based off of CFL Field Pool experience, historic EEBACS production rate data, and RS-Means data
- 73: There are multiple submittals that the contractor has to get approved prior to starting construction; these include: mix designs, concrete material FHWA verification testing, form and falsework drawings, rebar fabrication drawings, material certs and girder erection plans. Some of these submittals require . There is a minimum of 30 calendar days (20 work days) allowed for review, so add time for the contractor to get the submittals completed.
- 74: Surveying will probably take several days to layout the bridge. Survey will be ongoing for each stage of bridge construction.
- 75: ·Dewatering requirements and duration will be project dependent; give at least one day for smaller bridges with perennial flow that has to be diverted; for medium to larger bridges, dewatering work may take up to a few days; consider permit and T&E species requirements, and how they will impact the time it will take to dewater / Typical Cofferdam Production Rates/ ·Low = 100 SY/day / ·Average = 200 SY/day / ·High = 300 SY/day
- 76: The required duration for traffic diversion will be project specific. Give at least one day for small bridges that require a shoo-fly for traffic diversion. Give two or more days for larger bridges with higher flows.
- 77: Duration will be project dependent. / Typical Production rates/ ·Low = 500 SF/day / ·Medium = 1000 SF/day / ·High = 1500 SF/day / ·these rates are by SQFT of bridge deck / ·these rates include the time it takes to remove all structural components above the existing channel bottom. / ·These rates to not include removal of any approach fill or installation of any protective measures for keeping demolision debris out of the waterway
- 78: Typical Productions Rates/ ·Low = 10 LF/day / ·Average = 112 LF/day / ·High = 280 LF/day / ·Consider expected subgrade material; reduce rates slightly for cobbly soil and large diameter holes (greater than 36" dia.) / ·If the shafts are clustered and easily accessible the rates will be between 70 and 280 LF per day / ·Clusters are areas where shafts can be installed rather contiuously. / ·No difference was found between cased and uncased shafts for production / ·If testing (CSL, etc) is required, add testing time (in days) to the days based on production rates. CSL tests take approx. 30min per shaft
- 79: Typical Productions Rates/ ·Low = 100 LF/day / ·Average = 250 LF/day / ·High = 500 LF/day / ·Allow time for relaxation/testing/redriving
- 80: Typical Productions Rates/ ·Low = 100 LF/day / ·Average = 250 LF/day / ·High = 500 LF/day / ·Allow time for relaxation/testing/redriving
- 81: Typical Production Rates/ ·Low = 3000 Lbs/day / ·Average = 4000 Lbs/day / ·High = 5000 Lbs/day
- 82: Typical Production Rates/ ·Low = 20 CY/day / ·Medium = 110 CY/day / ·High = 200 CY/day / ·smaller structures will have lower production rates / ·consider likely haul distance of concrete trucks / ·consider accessibility of concrete trucks, pump trucks and any special application requirements (ie: pump truck, tremie, etc.) / ·consider traffic passage requirements
- 83: Discuss with Bridge to determine duration.
- 84: Typical Production Rates/ ·Low = 3 EA/day / ·Average = 6 EA/day / ·High = 12 EA/day / ·Use lower rates for poor access, larger/heavier girders / ·Typical production rate is one or two spans per day / ·Consider haul distance of girders from precast plant / ·Allow a minimum of 10 days for fabrication prior to this activity.
- 85: Typical Production Rates/ ·Low = 3 EA/day / ·Average = 6 EA/day / ·High = 12 EA/day / ·Use lower rates for poor access and larger/heavier beams / ·Typical production rate is one or two spans per day / ·Allow a minimum of 10 days for fabrication prior to this activity.
- 86: Typical Production Rates/ ·Low = 3000 Lbs/day / ·Average = 4400 Lbs/day / ·High = 5800 Lbs/day / ·Typical 3 days per span
- 87: For a typical CFLHD bridge, on-site survey will normally take one day for pre- concrete survey, and one day for post-concrete survey. Pre-concrete survey includes Bidwel rail survey. Post-concrete survey includes as-built survey of the deck (shots of top and bottom of deck and 10th points).
- 88: Typical Production Rates/ ·Low = 20 CY/day / ·Medium = 110 CY/day / ·High = 200 CY/day / ·smaller structures will have lower production rates / ·consider likely haul distance of concrete trucks / ·consider accessibility of concrete trucks, pump trucks and any special application requirements / ·consider traffic passage requirements
- 89: Typical Productions Rates/ ·Low = / ·Average = 5 days per span (limited data available) / ·High =
- 90: Typical Production Rates / ·Low = 10 SF/day / ·Average = 22 SF/day / ·High = 60 SF/day / ·Rates are based on SF of exposed face / ·Rates include forming, reinforcement and concrete pour (see note below) / NOTE: this activity should only be included in the schedule for Wingwalls if the wingwalls are not poured monalithically with the abutment and/or endwall of the bridge. Otherwise, include wingwall construction duration in the Substructure Reinforcement and Substructure Concrete activities.
- 91: ·remove this activity if wet tining and/or grooving will be allowed; include this activity if saw-cut grooving is required / ·Saw-cut grooving will typically be completed in one day; grooving can be completed at around 5,000 - 10,000sqft/day; larger bridges may take longer than one day
- 92: Typical Productions Rates/ ·Low = / ·Average = 1500 LF - Limited data available / ·High =
